# AB-08 - complex kantoorgebouw

Schedule from MS Project, 2003-01-12 to 2003-02-20, status date 2003-01-08.
BAM Nelissen Van Egteren

## Calendars

- ALLEEN WERKDAGEN: Mon-Fri 08:30-12:30, 13:00-17:00; Sat-Sun off. Exceptions (off unless hours are given): 2003-01-11 to 2003-01-12 08:30-12:30, 13:00-17:00, 2003-01-18 to 2003-01-19 08:30-12:30, 13:00-17:00, 2003-01-25 to 2003-01-26 08:30-12:30, 13:00-17:00, 2003-02-01 to 2003-02-02 08:30-12:30, 13:00-17:00, 2003-02-08 to 2003-02-09 08:30-12:30, 13:00-17:00, 2003-02-15 to 2003-02-16 08:30-12:30, 13:00-17:00.

## Schedule

| ID | WBS | Task | Type | Duration | Start | Finish | Predecessors | Total slack | Free slack |
| --- | --- | --- | --- | --- | --- | --- | --- | --- | --- |
| 1 | 1 | **AFBOUWFASE** |  | 40d | 2003-01-12 | 2003-02-20 |  | 0d |  |
| 2 | 1.1 | **inbouwfase** |  | 40d | 2003-01-12 | 2003-02-20 |  | 0d |  |
| 3 | 1.1.1 | plafond prim.leidingen vooraf | milestone | 0d | 2003-01-12 | 2003-01-12 |  | 40d |  |
| 4 | 1.1.2 | GM-wand frame+kozijnen |  | 5d | 2003-01-12 | 2003-01-16 |  | 20d | 0d |
| 5 | 1.1.3 | GM-wand 1e beplating aanbr. |  | 5d | 2003-01-15 | 2003-01-19 | 4SS+3d | 20d | 0d |
| 6 | 1.1.4 | GM-wand water+riolering |  | 5d | 2003-01-18 | 2003-01-22 | 5SS+3d | 20d | 0d |
| 7 | 1.1.5 | GM-wand electra leid.+dozen |  | 5d | 2003-01-20 | 2003-01-24 | 6SS+2d | 20d | 0d |
| 8 | 1.1.6 | GM-wand sluitwand aanbr. |  | 5d | 2003-01-23 | 2003-01-27 | 7SS+3d | 20d | 0d |
| 9 | 1.1.7 | GM-wand egaliseren |  | 5d | 2003-01-26 | 2003-01-30 | 8SS+3d | 20d | 0d |
| 10 | 1.1.8 | wand brandwerende afdicht. |  | 3d | 2003-01-29 | 2003-01-31 | 9SS+3d | 20d |  |
| 11 | 1.1.9 | plafond CV leidingset mont. |  | 5d | 2003-01-12 | 2003-01-16 |  | 0d |  |
| 12 | 1.1.10 | plafond luchtkanalen monteren |  | 5d | 2003-01-14 | 2003-01-18 | 11SS+2d | 0d |  |
| 13 | 1.1.11 | plafond sprinkler leidingen |  | 5d | 2003-01-16 | 2003-01-20 | 12SS+2d | 0d |  |
| 14 | 1.1.12 | plafond bekabeling in goten |  | 5d | 2003-01-18 | 2003-01-22 | 13SS+2d | 0d |  |
| 15 | 1.1.13 | plafond randlat aanbr. |  | 5d | 2003-01-20 | 2003-01-24 | 14SS+2d | 0d |  |
| 16 | 1.1.14 | plafond regeleenheid mont. |  | 5d | 2003-01-22 | 2003-01-26 | 15SS+2d | 0d |  |
| 17 | 1.1.15 | plafond bandraster mont. |  | 5d | 2003-01-23 | 2003-01-27 | 16SS+1d | 0d |  |
| 18 | 1.1.16 | plafond roosters mont. |  | 5d | 2003-01-25 | 2003-01-29 | 17SS+2d | 0d |  |
| 19 | 1.1.17 | plafond kabels in bandraster |  | 5d | 2003-01-25 | 2003-01-29 | 18SS | 0d |  |
| 20 | 1.1.18 | plafond sprinklerkoppen mont. |  | 5d | 2003-01-25 | 2003-01-29 | 19SS | 0d |  |
| 21 | 1.1.19 | vloer landata bekabeling |  | 5d | 2003-01-30 | 2003-02-03 | 20SS+5d | 0d |  |
| 22 | 1.1.20 | vloer spanningsrail mont. |  | 5d | 2003-02-01 | 2003-02-05 | 21SS+2d | 0d |  |
| 23 | 1.1.21 | vloer landata kabels aansluiten |  | 5d | 2003-02-03 | 2003-02-07 | 22SS+2d | 0d |  |
| 24 | 1.1.22 | vloer landatakabels testen |  | 2d | 2003-02-07 | 2003-02-08 | 23SS+4d | 0d |  |
| 25 | 1.1.23 | vloer tegels op poten mont. |  | 5d | 2003-02-09 | 2003-02-13 | 24SS+2d | 0d |  |
| 26 | 1.1.24 | bouwlaag opruimen |  | 2d | 2003-02-14 | 2003-02-15 | 25SS+5d | 0d |  |
| 27 | 1.1.25 | keuren bouw+installatie |  | 1d | 2003-02-16 | 2003-02-16 | 26SS+2d | 0d |  |
| 28 | 1.1.26 | herstelwerkzaamheden |  | 4d | 2003-02-17 | 2003-02-20 | 27SS+1d | 0d |  |
| 29 | 1.1.27 | keuringsrapport maken | milestone | 0d | 2003-02-20 | 2003-02-20 | 28SS+4d | 0d |  |

| ID | WBS | Task | Type | Duration | Start | Finish | Predecessors | Total slack | Free slack |
| --- | --- | --- | --- | --- | --- | --- | --- | --- | --- |
| 30 | 1.2 | **afwerkingsfase** |  | 35d | 2003-01-12 | 2003-02-15 |  | 5d |  |
| 31 | 1.2.1 | plafond platen inleggen |  | 5d | 2003-01-12 | 2003-01-16 |  | 5d | 0d |
| 32 | 1.2.2 | plafond koelpanelen inleggen |  | 5d | 2003-01-14 | 2003-01-18 | 31SS+2d | 5d | 0d |
| 33 | 1.2.3 | plafond sprinklerkoppen mont. |  | 5d | 2003-01-16 | 2003-01-20 | 32SS+2d | 5d | 0d |
| 34 | 1.2.4 | plafond sprinkler water test |  | 2d | 2003-01-20 | 2003-01-21 | 33SS+4d | 5d | 0d |
| 35 | 1.2.5 | plafond koelpanelen afpersen |  | 5d | 2003-01-22 | 2003-01-26 | 34SS+2d | 5d | 0d |
| 36 | 1.2.6 | plafond luchtkleppen inregelen |  | 5d | 2003-01-24 | 2003-01-28 | 35SS+2d | 5d | 0d |
| 37 | 1.2.7 | wand spuitwerk aanbrengen |  | 5d | 2003-01-27 | 2003-01-31 | 36SS+3d | 5d | 0d |
| 38 | 1.2.8 | wand bekleding aanbrengen |  | 5d | 2003-01-30 | 2003-02-03 | 37SS+3d | 5d | 0d |
| 39 | 1.2.9 | vloer parket leggen |  | 5d | 2003-02-02 | 2003-02-06 | 38SS+3d | 5d | 0d |
| 40 | 1.2.10 | vloer tapijt leggen |  | 5d | 2003-02-03 | 2003-02-07 | 39SS+1d | 5d | 0d |
| 41 | 1.2.11 | vloer parket+tapijt beschermen |  | 5d | 2003-02-05 | 2003-02-09 | 40SS+2d | 5d | 0d |
| 42 | 1.2.12 | bouwlaag opruimen |  | 2d | 2003-02-09 | 2003-02-10 | 41SS+4d | 5d | 0d |
| 43 | 1.2.13 | bouwlaag keuren afwerking |  | 1d | 2003-02-11 | 2003-02-11 | 42SS+2d | 5d | 0d |
| 44 | 1.2.14 | herstelwerkzaamheden |  | 4d | 2003-02-12 | 2003-02-15 | 43SS+1d | 5d | 0d |
| 45 | 1.2.15 | keuringsrapport maken | milestone | 0d | 2003-02-15 | 2003-02-15 | 44SS+4d | 5d |  |
| 46 | 1.3 | **uitrustingsfase** |  | 25d | 2003-01-12 | 2003-02-05 |  | 15d |  |
| 47 | 1.3.1 | systeemwanden monteren |  | 5d | 2003-01-12 | 2003-01-16 |  | 15d | 0d |
| 48 | 1.3.2 | binnendeuren afhangen |  | 5d | 2003-01-14 | 2003-01-18 | 47SS+2d | 15d | 0d |
| 49 | 1.3.3 | deuren hang+sluitwerk |  | 5d | 2003-01-16 | 2003-01-20 | 48SS+2d | 15d | 0d |
| 50 | 1.3.4 | sanitaire toestellen afmont. |  | 5d | 2003-01-17 | 2003-01-21 | 49SS+1d | 15d | 0d |
| 51 | 1.3.5 | kranen+accesoires afmont. |  | 5d | 2003-01-19 | 2003-01-23 | 50SS+2d | 15d | 0d |
| 52 | 1.3.6 | plafond armaturen afmont |  | 5d | 2003-01-21 | 2003-01-25 | 51SS+2d | 15d | 0d |
| 53 | 1.3.7 | electra schakelmateriaal afmont. |  | 5d | 2003-01-23 | 2003-01-27 | 52SS+2d | 15d | 0d |
| 54 | 1.3.8 | opleveringsfase |  | 1d | 2003-01-28 | 2003-01-28 | 53SS+5d | 15d | 0d |
| 55 | 1.3.9 | bouwlaag opruimen |  | 2d | 2003-01-29 | 2003-01-30 | 54SS+1d | 15d | 0d |
| 56 | 1.3.10 | bouwlaag keuren bouw+installatie |  | 2d | 2003-01-31 | 2003-02-01 | 55SS+2d | 15d | 0d |
| 57 | 1.3.11 | herstelwerkzaamheden |  | 4d | 2003-02-02 | 2003-02-05 | 56SS+2d | 15d | 0d |
| 58 | 1.3.12 | keuringsrapport maken | milestone | 0d | 2003-02-05 | 2003-02-05 | 57SS+4d | 15d |  |
